# PAQUETE R-07 DEFENSAS RIBEREÑAS DEL RÍO LACRAMARCA

Schedule from Primavera P6, 2024-11-01 to 2025-04-29, data date 2024-11-01, costs in PEN.

## Calendars

- Lacramarca (7d/10h): Mon-Sun 08:00-16:00. Exceptions (off unless hours are given): 2024-11-01 to 2025-04-29 07:00-12:00, 13:00-18:00.

## Resources

| Resource | Group | Rate |
| --- | --- | --- |
| Recurso Lacramarca | labor | 1 |
| Recurso Lacramarca - NLU | equipment |  |

## Schedule

| ID | WBS | Activity | Type | Duration | Start | Finish | Predecessors | Total float |
| --- | --- | --- | --- | --- | --- | --- | --- | --- |
|  | 501 | **DEFENSAS RIBEREÑAS** |  |  | 2024-11-01 | 2025-04-29 |  |  |
|  | P | **PROCURA** |  |  |  |  |  |  |
|  | 40 | **CONSULTOR ESPECIALIZADO** |  |  |  |  |  |  |
|  | 50 | **PROVEEDOR** |  |  |  |  |  |  |
|  | C | **CONSTRUCCIÓN** |  |  | 2024-11-01 | 2025-04-29 |  |  |
|  | 00 | **GENERAL** |  |  |  |  |  |  |
|  | 00 | **GENERAL** |  |  |  |  |  |  |
|  | 01 | **LIMPIEZA DE SITIO** |  |  |  |  |  |  |
|  | 10 | **SUBESTRUCTURA** |  |  |  |  |  |  |
|  | 01 | **FUNDACIONES ESTÁNDAR** |  |  |  |  |  |  |
|  | 02 | **CIMENTACIONES ESPECIALES** |  |  |  |  |  |  |
|  | 20 | **SUPERESTRUCTURA** |  |  |  |  |  |  |
|  | 01 | **MARCOS (CUBIERTAS)** |  |  |  |  |  |  |
|  | 03 | **TECHOS** |  |  |  |  |  |  |
|  | 04 | **ESCALERAS Y RAMPAS** |  |  |  |  |  |  |
|  | 05 | **MUROS EXTERIORES** |  |  |  |  |  |  |
|  | 09 | **PILARES DE PUENTE** |  |  |  |  |  |  |
|  | 10 | **ESTRIBOS DE PUENTE** |  |  |  |  |  |  |
|  | 11 | **CUBIERTAS DE PUENTE** |  |  |  |  |  |  |
|  | 12 | **PARAPETO DE PUENTE** |  |  |  |  |  |  |
|  | 25 | **INSTALACIONES ESPECIALES** |  |  |  |  |  |  |
|  | 01 | **APOYOS PARA PUENTES** |  |  |  |  |  |  |
|  | 30 | **ACABADOS** |  |  |  |  |  |  |
|  | 02 | **ACABADO PARA PISOS** |  |  |  |  |  |  |
|  | 60 | **TRABAJOS DE RENOVACIÓN** |  |  |  |  |  |  |
|  | 02 | **REPARACIÓN DE SERVICIOS EXISTENTES** |  |  |  |  |  |  |
|  | 70 | **OBRAS EXTERIORES** |  |  | 2024-11-01 | 2025-04-29 |  |  |
|  | 00 | **GENERAL** |  |  | 2024-11-01 | 2025-04-29 |  |  |
| C.70.00.10 |  | Inicio del Proyecto | milestone | 0d | 2024-11-01 | 2024-11-01 |  | 0d |
| C.70.00.20 |  | Fin del Proyecto | milestone | 0d | 2025-04-29 | 2025-04-29 | C.70.10.02.03.02.40, C.70.10.02.03.02.50, C.70.10.02.03.01.70, C.70.10.02.03.01.80, C.70.10.02.03.02.70, C.70.10.02.03.02.80, C.70.10.02.03.02.20, C.70.10.02.03.02.30, C.70.10.02.03.02.60, C.70.13.10, C.70.13.20, C.70.17.10, C.70.17.20, C.70.17.30, C.70.17.40, C.70.02.01, C.70.30.01, T.20.20.01, C.70.13.30, C.70.01.02 | 0d |

| ID | WBS | Activity | Type | Duration | Start | Finish | Predecessors | Total float | Free float | Resources | Cost | Lacramarca |
| --- | --- | --- | --- | --- | --- | --- | --- | --- | --- | --- | --- | --- |
|  | 01 | **PREPARACIÓN DE SITIO** |  |  | 2024-11-01 | 2025-04-29 |  |  |  |  |  |  |
| C.70.01.01 |  | Obras provisionales |  | 7d | 2024-11-01 | 2024-11-07 | C.70.00.10 | 0d |  | Recurso Lacramarca [437781 h]; Recurso Lacramarca - NLU [50.15 h] | 437,781.16 |  |
| C.70.01.02 |  | Topografía |  | 173d | 2024-11-08 | 2025-04-29 | C.70.01.01 | 0d |  | Recurso Lacramarca [1608682 h]; Recurso Lacramarca - NLU [10734.4 h] | 1,608,681.61 |  |
|  | 02 | **CAMINOS PROVISIONALES** |  |  | 2024-11-08 | 2025-04-29 |  |  |  |  |  |  |
| C.70.02.01 |  | Mantenimiento de tránsito y seguridad vial | level of effort | 173d | 2024-11-08 | 2025-04-29 | C.70.01.01 | 0d |  | Recurso Lacramarca [2171595 h]; Recurso Lacramarca - NLU [11427.3 h] | 2,171,594.62 |  |
|  | 03 | **PLANTACIÓN Y PAISAJISMO** |  |  | 2025-04-08 | 2025-04-29 |  |  |  |  |  |  |
| C.70.30.01 |  | Arquitectura y paisajismo | level of effort | 22d | 2025-04-08 | 2025-04-29 | C.70.10.02.02.80, C.70.10.02.02.70 | 0d |  | Recurso Lacramarca [126506 h]; Recurso Lacramarca - NLU [625.85 h] | 126,505.68 |  |
|  | 05 | **MOBILIARIO Y EQUIPAMIENTO URBANO** |  |  |  |  |  |  |  |  |  |  |
|  | 10 | **CUERPOS DE TERRAPLÉN** |  |  | 2024-11-08 | 2025-04-29 |  |  |  |  |  |  |
|  | 01 | **MARGEN DERECHO** |  |  | 2024-11-08 | 2025-02-06 |  |  |  |  |  |  |
|  | 01 | **TERRAPLÉN A3-D-01** |  |  | 2024-11-08 | 2024-12-30 |  |  |  |  |  |  |
| C.70.10.01.01.10 |  | Descolmatación (C1) - 1er Tramo |  | 8d | 2024-11-08 | 2024-11-15 | C.70.01.01 | 0d |  | Recurso Lacramarca [254458 h]; Recurso Lacramarca - NLU [1127.72 h] | 254,457.87 | D |
| C.70.10.01.01.20 |  | Excavación (C1) - 1er Tramo |  | 5d | 2024-11-16 | 2024-11-20 | C.70.10.01.01.10, C.70.01.01 | 0d |  | Recurso Lacramarca [69006.2 h]; Recurso Lacramarca - NLU [362.75 h] | 69,006.21 | E |
| C.70.10.01.01.30 |  | Excavación de Uña (C1) - 1er Tramo |  | 5d | 2024-11-16 | 2024-11-20 | C.70.10.01.01.10, C.70.01.01 | 0d |  | Recurso Lacramarca [24166.8 h]; Recurso Lacramarca - NLU [144.77 h] | 24,166.84 | E |
| C.70.10.01.01.40 |  | Relleno de Cuerpo (C1) - 1er Tramo |  | 9d | 2024-11-21 | 2024-11-29 | C.70.10.01.01.20, C.70.10.01.01.30, C.70.10.01.01.10, C.70.01.01 | 0d |  | Recurso Lacramarca [282767 h]; Recurso Lacramarca - NLU [2286.47 h] | 282,767.29 | R |
| C.70.10.01.01.50 |  | Relleno de Corona (C1) - 1er Tramo |  | 9d | 2024-11-21 | 2024-11-29 | C.70.10.01.01.20, C.70.10.01.01.30, C.70.10.01.01.10, C.70.01.01 | 0d |  | Recurso Lacramarca [253683 h]; Recurso Lacramarca - NLU [2203.77 h] | 253,682.86 | R |
| C.70.10.01.01.60 |  | Geotextil (C1) -1er Tramo |  | 5d | 2024-11-25 | 2024-11-29 | C.70.10.01.01.50 SS+4d, C.70.10.01.01.40 SS+4d, C.70.10.01.01.10, C.70.10.01.01.20, C.70.10.01.01.30 | 0d |  | Recurso Lacramarca [40202.1 h]; Recurso Lacramarca - NLU [310.95 h] | 40,202.14 | G |
| C.70.10.01.01.70 |  | Enrocado de Uña (C1) - 1er Tramo |  | 31d | 2024-11-30 | 2024-12-30 | C.70.10.01.01.60, C.70.10.01.01.20, C.70.10.01.01.30, C.70.10.01.01.40, C.70.10.01.01.50, C.70.10.01.01.10 | 0d |  | Recurso Lacramarca [323235 h]; Recurso Lacramarca - NLU [3062.39 h] | 323,234.66 | N |
| C.70.10.01.01.80 |  | Enrocado de Talud (C1) - 1er Tramo |  | 31d | 2024-11-30 | 2024-12-30 | C.70.10.01.01.60, C.70.10.01.01.20, C.70.10.01.01.30, C.70.10.01.01.40, C.70.10.01.01.50, C.70.10.01.01.10 | 0d |  | Recurso Lacramarca [427127 h]; Recurso Lacramarca - NLU [3459.61 h] | 427,127.21 | N |
|  | 02 | **TERRAPLÉN A3-D-02** |  |  | 2024-11-08 | 2025-02-06 |  |  |  |  |  |  |
|  | 01 | **Tramo 01** |  |  | 2024-11-16 | 2025-01-08 |  |  |  |  |  |  |
| C.70.10.01.02.01.10 |  | Descolmatación (C1) - 1er Tramo |  | 1d | 2024-11-16 | 2024-11-16 | C.70.10.01.01.10, C.70.01.01 | 24d | 0d | Recurso Lacramarca [35689.9 h]; Recurso Lacramarca - NLU [157.07 h] | 35,689.93 | D |
| C.70.10.01.02.01.20 |  | Excavación (C1) - 1er Tramo |  | 2d | 2024-11-21 | 2024-11-22 | C.70.10.01.01.20, C.70.01.01 | 18d | 0d | Recurso Lacramarca [22199.9 h]; Recurso Lacramarca - NLU [117.52 h] | 22,199.88 | E |
| C.70.10.01.02.01.30 |  | Excavación de Uña (C1) - 1er Tramo |  | 2d | 2024-11-21 | 2024-11-22 | C.70.10.01.01.30, C.70.01.01 | 18d | 0d | Recurso Lacramarca [8975.38 h]; Recurso Lacramarca - NLU [54.04 h] | 8,975.38 | E |
| C.70.10.01.02.01.40 |  | Relleno de Cuerpo (C1) - 1er Tramo |  | 2d | 2024-11-29 | 2024-11-30 | C.70.10.01.01.40 SS+8d, C.70.10.01.01.50 SS+8d, C.70.01.01 | 24d | 0d | Recurso Lacramarca [60385.7 h]; Recurso Lacramarca - NLU [495.56 h] | 60,385.66 | R |
| C.70.10.01.02.01.50 |  | Relleno de Corona (C1) - 1er Tramo |  | 2d | 2024-11-29 | 2024-11-30 | C.70.10.01.01.50 SS+8d, C.70.01.01 | 24d | 0d | Recurso Lacramarca [56768.7 h]; Recurso Lacramarca - NLU [492.24 h] | 56,768.65 | R |
| C.70.10.01.02.01.60 |  | Geotextil (C1) -1er Tramo |  | 1d | 2024-12-01 | 2024-12-01 | C.70.10.01.01.60, C.70.10.01.02.01.40, C.70.10.01.02.01.50 | 24d | 6d | Recurso Lacramarca [8666.74 h]; Recurso Lacramarca - NLU [67.03 h] | 8,666.74 | G |
| C.70.10.01.02.01.70 |  | Enrocado de Uña (C1) - 1er Tramo |  | 9d | 2024-12-31 | 2025-01-08 | C.70.10.01.01.70, C.70.10.01.01.80, C.70.10.01.02.01.60, C.70.10.01.02.01.40, C.70.10.01.02.01.50, C.70.10.01.02.01.10, C.70.10.01.02.01.20, C.70.10.01.02.01.30 | 30d | 0d | Recurso Lacramarca [123083 h]; Recurso Lacramarca - NLU [1070.72 h] | 123,082.59 | N |
| C.70.10.01.02.01.80 |  | Enrocado de Talud (C1) - 1er Tramo |  | 9d | 2024-12-31 | 2025-01-08 | C.70.10.01.01.80, C.70.10.01.01.70, C.70.10.01.02.01.60, C.70.10.01.02.01.40, C.70.10.01.02.01.50, C.70.10.01.02.01.10, C.70.10.01.02.01.20, C.70.10.01.02.01.30 | 30d | 0d | Recurso Lacramarca [166003 h]; Recurso Lacramarca - NLU [1206.44 h] | 166,002.74 | N |

| ID | WBS | Activity | Duration | Start | Finish | Predecessors | Total float | Free float | Resources | Cost | Lacramarca |
| --- | --- | --- | --- | --- | --- | --- | --- | --- | --- | --- | --- |
|  | 02 | **Tramo 02** |  | 2024-11-17 | 2025-02-06 |  |  |  |  |  |  |
| C.70.10.01.02.02.10 |  | Descolmatación (C1) - 2do Tramo | 20d | 2024-11-17 | 2024-12-06 | C.70.10.01.02.01.10, C.70.01.01 | 24d |  | Recurso Lacramarca [713799 h]; Recurso Lacramarca - NLU [3141.36 h] | 713,798.64 | D |
| C.70.10.01.02.02.20 |  | Excavación (C1) - 2do Tramo | 19d | 2024-11-23 | 2024-12-11 | C.70.10.01.02.01.20, C.70.01.01 | 30d | 28d | Recurso Lacramarca [210899 h]; Recurso Lacramarca - NLU [1116.37 h] | 210,898.87 | E |
| C.70.10.01.02.02.30 |  | Excavación de Uña (C1) - 2do Tramo | 19d | 2024-11-23 | 2024-12-11 | C.70.10.01.02.01.30, C.70.01.01 | 30d | 28d | Recurso Lacramarca [85266.1 h]; Recurso Lacramarca - NLU [513.33 h] | 85,266.06 | E |
| C.70.10.01.02.02.40 |  | Relleno de Cuerpo (C1) - 2do Tramo | 21d | 2024-12-01 | 2024-12-21 | C.70.10.01.02.01.40, C.70.10.01.01.40, C.70.10.01.01.50, C.70.01.01 | 29d | 0d | Recurso Lacramarca [634049 h]; Recurso Lacramarca - NLU [5203.31 h] | 634,049.44 | R |
| C.70.10.01.02.02.50 |  | Relleno de Corona (C1) - 2do Tramo | 21d | 2024-12-01 | 2024-12-21 | C.70.10.01.02.01.50, C.70.10.01.01.40, C.70.10.01.01.50, C.70.01.01 | 29d | 0d | Recurso Lacramarca [596071 h]; Recurso Lacramarca - NLU [5168.48 h] | 596,070.84 | R |
| C.70.10.01.02.02.60 |  | Geotextil (C1) -2do Tramo | 7d | 2024-12-16 | 2024-12-22 | C.70.10.01.02.01.60, C.70.10.01.02.02.40 SS+15d, C.70.10.01.02.02.50 SS+15d | 36d | 17d | Recurso Lacramarca [60667.2 h]; Recurso Lacramarca - NLU [469.24 h] | 60,667.21 | G |
| C.70.10.01.02.02.70 |  | Enrocado de Uña (C3,C4) - 2do Tramo | 29d | 2025-01-09 | 2025-02-06 | C.70.10.01.02.01.70, C.70.10.01.02.01.80, C.70.10.01.02.02.60, C.70.10.01.02.02.40, C.70.10.01.02.02.50, C.70.10.01.02.02.10, C.70.10.01.02.02.20, C.70.10.01.02.02.30 | 30d | 23d | Recurso Lacramarca [396599 h]; Recurso Lacramarca - NLU [3450.1 h] | 396,599.47 | N |
| C.70.10.01.02.02.80 |  | Enrocado de Talud (C3,C4) - 2do Tramo | 29d | 2025-01-09 | 2025-02-06 | C.70.10.01.02.01.70, C.70.10.01.02.01.80, C.70.10.01.02.02.60, C.70.10.01.02.02.40, C.70.10.01.02.02.50, C.70.10.01.02.02.10, C.70.10.01.02.02.20, C.70.10.01.02.02.30 | 30d | 23d | Recurso Lacramarca [534898 h]; Recurso Lacramarca - NLU [3887.41 h] | 534,897.73 | N |
|  | 03 | **Tramo 03** |  | 2024-11-08 | 2025-02-06 |  |  |  |  |  |  |
| C.70.10.01.02.03.10 |  | Descolmatación (C2) - 3er Tramo | 20d | 2024-11-08 | 2024-11-27 | C.70.01.01 | 20d | 2d | Recurso Lacramarca [713799 h]; Recurso Lacramarca - NLU [3141.36 h] | 713,798.64 | D |
| C.70.10.01.02.03.20 |  | Excavación (C2) - 3er Tramo | 18d | 2024-11-23 | 2024-12-10 | C.70.10.01.02.01.20 SS+2d, C.70.01.01, C.70.10.01.01.20 | 18d | 0d | Recurso Lacramarca [199799 h]; Recurso Lacramarca - NLU [1057.62 h] | 199,798.93 | E |
| C.70.10.01.02.03.30 |  | Excavación de Uña (C2) - 3er Tramo | 18d | 2024-11-23 | 2024-12-10 | C.70.10.01.02.01.30, C.70.01.01, C.70.10.01.01.20 | 18d | 0d | Recurso Lacramarca [80778.4 h]; Recurso Lacramarca - NLU [486.31 h] | 80,778.37 | E |
| C.70.10.01.02.03.40 |  | Relleno de Cuerpo (C2) - 3er Tramo | 21d | 2024-11-30 | 2024-12-20 | C.70.10.01.02.03.20 SS+7d, C.70.10.01.02.03.30 SS+7d, C.70.10.01.02.03.10, C.70.01.01 | 18d | 0d | Recurso Lacramarca [634049 h]; Recurso Lacramarca - NLU [5203.31 h] | 634,049.44 | R |
| C.70.10.01.02.03.50 |  | Relleno de Corona (C2) - 3er Tramo | 21d | 2024-11-30 | 2024-12-20 | C.70.10.01.02.03.20 SS+7d, C.70.10.01.02.03.30 SS+7d, C.70.10.01.02.03.10, C.70.01.01 | 18d | 0d | Recurso Lacramarca [596071 h]; Recurso Lacramarca - NLU [5168.48 h] | 596,070.84 | R |
| C.70.10.01.02.03.60 |  | Geotextil (C2) -3er Tramo | 13d | 2024-12-08 | 2024-12-20 | C.70.10.01.02.01.60, C.70.10.01.02.03.40 SS+8d, C.70.10.01.02.03.50 SS+8d, C.70.10.01.02.03.10, C.70.10.01.01.60 | 18d | 0d | Recurso Lacramarca [112668 h]; Recurso Lacramarca - NLU [871.45 h] | 112,667.67 | G |
| C.70.10.01.02.03.70 |  | Enrocado de Uña (C1,C2) - 3er Tramo | 60d | 2024-12-09 | 2025-02-06 | C.70.10.01.02.03.60 SS+1d, C.70.10.01.02.03.10 | 18d |  | Recurso Lacramarca [820551 h]; Recurso Lacramarca - NLU [7138.15 h] | 820,550.63 | N |
| C.70.10.01.02.03.80 |  | Enrocado de Talud (C1,C2) - 3er Tramo | 60d | 2024-12-09 | 2025-02-06 | C.70.10.01.02.03.60 SS+1d, C.70.10.01.02.03.10 | 18d |  | Recurso Lacramarca [1106685 h]; Recurso Lacramarca - NLU [8042.91 h] | 1,106,684.96 | N |
|  | 02 | **MARGEN IZQUIERDO** |  | 2024-12-31 | 2025-04-29 |  |  |  |  |  |  |
|  | 01 | **TERRAPLÉN A3-I-01** |  | 2024-12-31 | 2025-02-28 |  |  |  |  |  |  |
| C.70.10.02.01.10 |  | Descolmatación (C1) - 1er Tramo | 27d | 2024-12-31 | 2025-01-26 | C.70.10.01.01.70, C.70.10.01.01.80, C.70.10.01.01.10, C.70.10.01.02.02.10, C.70.10.01.02.03.10, C.70.01.01 | 0d |  | Recurso Lacramarca [807029 h]; Recurso Lacramarca - NLU [3591.36 h] | 807,028.94 | D |
| C.70.10.02.01.20 |  | Excavación (C1) - 1er Tramo | 17d | 2025-01-11 | 2025-01-27 | C.70.10.02.01.10 SS+11d, C.70.10.01.01.20, C.70.10.01.01.30, C.70.10.01.01.40, C.70.10.01.02.03.20, C.70.10.01.02.03.30, C.70.10.01.02.02.20, C.70.10.01.02.02.30, C.70.01.01 | 0d |  | Recurso Lacramarca [65556.7 h]; Recurso Lacramarca - NLU [370.08 h] | 65,556.7 | E |
| C.70.10.02.01.30 |  | Excavación de Uña (C1) - 1er Tramo | 17d | 2025-01-11 | 2025-01-27 | C.70.10.02.01.20 SS, C.70.10.02.01.10 SS+11d, C.70.10.01.01.20, C.70.10.01.01.30, C.70.10.01.02.03.20, C.70.10.01.02.03.30, C.70.10.01.02.02.20, C.70.10.01.02.02.30, C.70.01.01 | 0d |  | Recurso Lacramarca [28574.3 h]; Recurso Lacramarca - NLU [191.98 h] | 28,574.34 | E |
| C.70.10.02.01.40 |  | Relleno de Cuerpo (C1) - 1er Tramo | 12d | 2025-01-20 | 2025-01-31 | C.70.10.02.01.20 SS+9d, C.70.10.01.01.40, C.70.10.01.01.50, C.70.10.02.01.30 SS+9d, C.70.10.01.02.02.40, C.70.10.01.02.02.50, C.70.10.01.02.03.40, C.70.10.01.02.03.50, C.70.01.01 | 0d |  | Recurso Lacramarca [407559 h]; Recurso Lacramarca - NLU [3204.95 h] | 407,559.04 | R |
| C.70.10.02.01.50 |  | Relleno de Corona (C1) - 1er Tramo | 12d | 2025-01-20 | 2025-01-31 | C.70.10.02.01.20 SS+9d, C.70.10.01.01.40, C.70.10.01.01.50, C.70.10.02.01.30 SS+9d, C.70.10.01.02.02.40, C.70.10.01.02.02.50, C.70.10.01.02.03.40, C.70.10.01.02.03.50, C.70.01.01 | 0d |  | Recurso Lacramarca [319390 h]; Recurso Lacramarca - NLU [2818.42 h] | 319,389.76 | R |
| C.70.10.02.01.60 |  | Geotextil (C1) -1er Tramo | 5d | 2025-01-28 | 2025-02-01 | C.70.10.02.01.40 SS+8d, C.70.10.02.01.50 SS+8d, C.70.10.01.01.60, C.70.10.01.02.01.60, C.70.10.01.02.02.60, C.70.10.01.02.03.60 | 0d |  | Recurso Lacramarca [39416.1 h]; Recurso Lacramarca - NLU [304.87 h] | 39,416.05 | G |
| C.70.10.02.01.70 |  | Enrocado de Uña (C1) - 1er Tramo | 30d | 2025-01-30 | 2025-02-28 | C.70.10.02.01.60 SS+2d, C.70.10.01.01.70, C.70.10.01.01.80, C.70.10.02.01.10 | 0d |  | Recurso Lacramarca [313675 h]; Recurso Lacramarca - NLU [2968.99 h] | 313,675.29 | N |
| C.70.10.02.01.80 |  | Enrocado de Talud (C1) - 1er Tramo | 30d | 2025-01-30 | 2025-02-28 | C.70.10.02.01.60 SS+2d, C.70.10.01.01.80, C.70.10.01.01.70, C.70.10.02.01.10 | 0d |  | Recurso Lacramarca [418462 h]; Recurso Lacramarca - NLU [3377.17 h] | 418,462.36 | N |

| ID | WBS | Activity | Duration | Start | Finish | Predecessors | Total float | Free float | Resources | Cost | Lacramarca |
| --- | --- | --- | --- | --- | --- | --- | --- | --- | --- | --- | --- |
|  | 02 | **TERRAPLÉN A3-I-02** |  | 2025-01-27 | 2025-04-07 |  |  |  |  |  |  |
| C.70.10.02.02.10 |  | Descolmatación (C1) - 2do Tramo | 8d | 2025-01-27 | 2025-02-03 | C.70.10.02.01.10, C.70.01.01, C.70.10.01.02.03.10, C.70.10.01.02.02.10, C.70.10.01.02.01.10, C.70.10.01.01.10 | 0d |  | Recurso Lacramarca [347084 h]; Recurso Lacramarca - NLU [1511.88 h] | 347,083.59 | D |
| C.70.10.02.02.20 |  | Excavación (C1) - 2do Tramo | 23d | 2025-01-28 | 2025-02-19 | C.70.10.02.01.30, C.70.10.02.01.20, C.70.10.02.01.10, C.70.01.01, C.70.10.01.02.03.20, C.70.10.01.02.03.30, C.70.10.01.02.02.20, C.70.10.01.02.02.30 | 0d |  | Recurso Lacramarca [82379.9 h]; Recurso Lacramarca - NLU [468.44 h] | 82,379.92 | E |
| C.70.10.02.02.30 |  | Excavación de Uña (C1) - 2do Tramo | 23d | 2025-01-28 | 2025-02-19 | C.70.10.02.01.30, C.70.10.02.01.20, C.70.10.02.02.10 SS+1d, C.70.10.02.01.10, C.70.01.01, C.70.10.01.02.03.20, C.70.10.01.02.03.30, C.70.10.01.02.02.20, C.70.10.01.02.02.30 | 0d |  | Recurso Lacramarca [38872.6 h]; Recurso Lacramarca - NLU [260.93 h] | 38,872.57 | E |
| C.70.10.02.02.40 |  | Relleno de Cuerpo (C1) - 2do Tramo | 7d | 2025-02-20 | 2025-02-26 | C.70.10.02.01.40, C.70.10.02.01.50, C.70.10.02.02.20, C.70.10.02.02.30, C.70.01.01, C.70.10.01.02.03.40, C.70.10.01.02.03.50 | 7d | 0d | Recurso Lacramarca [184927 h]; Recurso Lacramarca - NLU [1599.17 h] | 184,926.86 | R |
| C.70.10.02.02.50 |  | Relleno de Corona (C1) - 2do Tramo | 7d | 2025-02-20 | 2025-02-26 | C.70.10.02.01.40, C.70.10.02.01.50, C.70.10.02.02.20, C.70.10.02.02.30, C.70.01.01, C.70.10.01.02.03.40, C.70.10.01.02.03.50 | 7d | 0d | Recurso Lacramarca [217757 h]; Recurso Lacramarca - NLU [1844.11 h] | 217,756.72 | R |
| C.70.10.02.02.60 |  | Geotextil (C1) -2do Tramo | 5d | 2025-02-27 | 2025-03-03 | C.70.10.02.01.60, C.70.10.02.02.40, C.70.10.02.02.50, C.70.10.01.02.03.60, C.70.10.01.02.02.60, C.70.10.01.02.01.60, C.70.10.01.01.60 | 7d | 0d | Recurso Lacramarca [35497.8 h]; Recurso Lacramarca - NLU [274.56 h] | 35,497.8 | G |
| C.70.10.02.02.70 |  | Enrocado de Uña (C1) - 2do Tramo | 37d | 2025-03-02 | 2025-04-07 | C.70.10.02.02.60 SS+3d, C.70.10.02.01.70, C.70.10.02.01.80, C.70.10.01.02.02.70, C.70.10.01.02.02.80 | 7d | 0d | Recurso Lacramarca [396877 h]; Recurso Lacramarca - NLU [3723.94 h] | 396,876.66 | N |
| C.70.10.02.02.80 |  | Enrocado de Talud (C1) - 2do Tramo | 37d | 2025-03-02 | 2025-04-07 | C.70.10.02.02.60 SS+3d, C.70.10.02.01.70, C.70.10.02.01.80, C.70.10.01.02.02.70, C.70.10.01.02.02.80 | 7d | 0d | Recurso Lacramarca [488207 h]; Recurso Lacramarca - NLU [4017.72 h] | 488,206.83 | N |
|  | 03 | **TERRAPLÉN A3-I-03** |  | 2025-01-21 | 2025-04-29 |  |  |  |  |  |  |
|  | 01 | **Tramo 03** |  | 2025-02-04 | 2025-04-22 |  |  |  |  |  |  |
| C.70.10.02.03.01.10 |  | Descolmatación (C1) - 3er Tramo | 7d | 2025-02-04 | 2025-02-10 | C.70.10.02.02.10, C.70.01.01, C.70.10.02.01.10, C.70.10.01.02.03.10, C.70.10.01.02.02.10, C.70.10.01.02.01.10, C.70.10.01.01.10 | 35d | 9d | Recurso Lacramarca [246397 h]; Recurso Lacramarca - NLU [1085.24 h] | 246,396.59 | D |
| C.70.10.02.03.01.20 |  | Excavación (C1) - 3er Tramo | 20d | 2025-02-20 | 2025-03-11 | C.70.10.02.02.20, C.70.10.02.03.01.10, C.70.01.01 | 26d | 0d | Recurso Lacramarca [128667 h]; Recurso Lacramarca - NLU [698.56 h] | 128,667.05 | E |
| C.70.10.02.03.01.30 |  | Excavación de Uña (C1) - 3er Tramo | 20d | 2025-02-20 | 2025-03-11 | C.70.10.02.02.30, C.70.10.02.03.01.10, C.70.01.01 | 26d | 0d | Recurso Lacramarca [54985.5 h]; Recurso Lacramarca - NLU [345.57 h] | 54,985.51 | E |
| C.70.10.02.03.01.40 |  | Relleno de Cuerpo (C1) - 3er Tramo | 7d | 2025-03-12 | 2025-03-18 | C.70.10.02.02.40, C.70.10.02.02.50, C.70.10.02.03.01.20, C.70.10.02.03.01.30, C.70.01.01, C.70.10.02.01.40, C.70.10.02.01.50 | 26d | 0d | Recurso Lacramarca [214275 h]; Recurso Lacramarca - NLU [1749.41 h] | 214,275.25 | R |
| C.70.10.02.03.01.50 |  | Relleno de Corona (C1) - 3er Tramo | 7d | 2025-03-12 | 2025-03-18 | C.70.10.02.02.40, C.70.10.02.02.50, C.70.10.02.03.01.20, C.70.10.02.03.01.30, C.70.01.01, C.70.10.02.01.40, C.70.10.02.01.50 | 26d | 0d | Recurso Lacramarca [201020 h]; Recurso Lacramarca - NLU [1737.64 h] | 201,019.64 | R |
| C.70.10.02.03.01.60 |  | Geotextil (C1) -3er Tramo | 4d | 2025-03-16 | 2025-03-19 | C.70.10.02.03.01.40 SS+4d, C.70.10.02.03.01.50 SS+4d, C.70.10.02.02.60, C.70.10.02.03.01.20, C.70.10.02.03.01.30, C.70.10.02.01.60, C.70.10.01.02.03.60, C.70.10.01.02.02.60, C.70.10.01.02.01.60, C.70.10.01.01.60 | 26d | 19d | Recurso Lacramarca [19105.6 h]; Recurso Lacramarca - NLU [147.78 h] | 19,105.64 | G |
| C.70.10.02.03.01.70 |  | Enrocado de Uña (C1) - 3er Tramo | 15d | 2025-04-08 | 2025-04-22 | C.70.10.02.03.01.60, C.70.10.02.02.70, C.70.10.02.02.80, C.70.10.02.03.01.40, C.70.10.02.03.01.50 | 7d |  | Recurso Lacramarca [207094 h]; Recurso Lacramarca - NLU [1796.69 h] | 207,094.41 | N |
| C.70.10.02.03.01.80 |  | Enrocado de Talud (C1) - 3er Tramo | 15d | 2025-04-08 | 2025-04-22 | C.70.10.02.03.01.60, C.70.10.02.02.70, C.70.10.02.02.80, C.70.10.02.03.01.40, C.70.10.02.03.01.50 | 7d |  | Recurso Lacramarca [282318 h]; Recurso Lacramarca - NLU [2039.18 h] | 282,317.84 | N |
|  | 02 | **Tramo 04** |  | 2025-01-21 | 2025-04-29 |  |  |  |  |  |  |
| C.70.10.02.03.02.10 |  | Descolmatación (C1) - 4to Tramo | 21d | 2025-01-21 | 2025-02-10 | C.70.10.02.01.10 SS+21d, C.70.01.01, C.70.10.01.02.03.10, C.70.10.01.02.02.10, C.70.10.01.02.01.10, C.70.10.01.01.10 | 9d | 0d | Recurso Lacramarca [739190 h]; Recurso Lacramarca - NLU [3255.73 h] | 739,189.8 | D |
| C.70.10.02.03.02.20 |  | Excavación (C1) - 4to Tramo | 36d | 2025-02-04 | 2025-03-11 | C.70.10.02.01.20, C.70.10.02.01.30, C.70.10.02.03.02.10 SS+14d, C.70.10.01.02.03.20, C.70.10.01.02.03.30, C.70.01.01 | 49d |  | Recurso Lacramarca [231601 h]; Recurso Lacramarca - NLU [1257.38 h] | 231,600.66 | E |
| C.70.10.02.03.02.30 |  | Excavación de Uña (C1) - 4to Tramo | 36d | 2025-02-04 | 2025-03-11 | C.70.10.02.01.20, C.70.10.02.01.30, C.70.10.02.03.02.10 SS+14d, C.70.10.01.02.03.20, C.70.10.01.02.03.30, C.70.01.01 | 49d |  | Recurso Lacramarca [98973.9 h]; Recurso Lacramarca - NLU [622 h] | 98,973.89 | E |
| C.70.10.02.03.02.40 |  | Relleno de Cuerpo (C1) - 4to Tramo | 27d | 2025-02-20 | 2025-03-18 | C.70.10.02.02.20, C.70.10.02.02.30, C.70.10.02.03.02.10, C.70.01.01 | 0d |  | Recurso Lacramarca [826490 h]; Recurso Lacramarca - NLU [6747.74 h] | 826,490.25 | R |
| C.70.10.02.03.02.50 |  | Relleno de Corona (C1) - 4to Tramo | 27d | 2025-02-20 | 2025-03-18 | C.70.10.02.02.20, C.70.10.02.02.30, C.70.10.02.03.02.10, C.70.01.01 | 0d |  | Recurso Lacramarca [775361 h]; Recurso Lacramarca - NLU [6702.35 h] | 775,361.48 | R |
| C.70.10.02.03.02.60 |  | Geotextil (C1) -4to Tramo | 27d | 2025-02-22 | 2025-03-20 | C.70.10.02.03.02.40 SS+2d, C.70.10.02.03.02.50 SS+2d, C.70.10.02.01.60, C.70.10.02.03.02.10, C.70.10.01.02.03.60, C.70.10.01.02.02.60, C.70.10.01.02.01.60, C.70.10.01.01.60 | 0d |  | Recurso Lacramarca [128963 h]; Recurso Lacramarca - NLU [997.48 h] | 128,963.06 | G |
| C.70.10.02.03.02.70 |  | Enrocado de Uña (C1) - 4to Tramo | 64d | 2025-02-25 | 2025-04-29 | C.70.10.02.03.02.60 SS+3d, C.70.10.02.03.02.10, C.70.10.01.02.03.70, C.70.10.01.02.03.80 | 0d |  | Recurso Lacramarca [883603 h]; Recurso Lacramarca - NLU [7665.89 h] | 883,602.82 | N |
| C.70.10.02.03.02.80 |  | Enrocado de Talud (C1) - 4to Tramo | 64d | 2025-02-25 | 2025-04-29 | C.70.10.02.03.02.60 SS+3d, C.70.10.02.03.02.10, C.70.10.01.02.03.70, C.70.10.01.02.03.80 | 0d |  | Recurso Lacramarca [1204556 h]; Recurso Lacramarca - NLU [8700.47 h] | 1,204,556.13 | N |

| ID | WBS | Activity | Type | Duration | Start | Finish | Predecessors | Total float | Free float | Resources | Cost |
| --- | --- | --- | --- | --- | --- | --- | --- | --- | --- | --- | --- |
|  | 11 | **SUPERFICIES DE TERRAPLÉN** |  |  |  |  |  |  |  |  |  |
|  | 12 | **MEJORAS EN LOS TERRAPLENES** |  |  |  |  |  |  |  |  |  |
|  | 13 | **CANALIZACIÓN** |  |  | 2025-03-01 | 2025-04-20 |  |  |  |  |  |
| C.70.13.10 |  | Canal C2 - 1er Tramo |  | 15d | 2025-03-01 | 2025-03-15 | C.70.10.02.01.70, C.70.01.01, C.70.10.02.01.80, C.70.10.02.01.10, C.70.10.02.01.20, C.70.10.02.01.30, C.70.10.02.01.40, C.70.10.02.01.50, C.70.10.02.01.60 | 9d | 0d | Recurso Lacramarca [1477550 h]; Recurso Lacramarca - NLU [16895.2 h] | 1,477,549.81 |
| C.70.13.20 |  | Canal C2 - 2do Tramo |  | 15d | 2025-03-16 | 2025-03-30 | C.70.13.10, C.70.10.02.01.10, C.70.10.02.01.20, C.70.10.02.01.30, C.70.10.02.01.40, C.70.10.02.01.50, C.70.10.02.01.60, C.70.10.02.01.70, C.70.10.02.01.80 | 9d | 0d | Recurso Lacramarca [277751 h]; Recurso Lacramarca - NLU [2619.64 h] | 277,751.16 |
| C.70.13.30 |  | Rampas |  | 21d | 2025-03-31 | 2025-04-20 | C.70.13.20, C.70.13.10, C.70.10.02.01.10, C.70.10.02.01.20, C.70.10.02.01.30, C.70.10.02.01.40, C.70.10.02.01.50, C.70.10.02.01.60, C.70.10.02.01.70, C.70.10.02.01.80 | 9d |  | Recurso Lacramarca [23309.5 h]; Recurso Lacramarca - NLU [125.56 h] | 23,309.47 |
|  | 14 | **REFUERZO DE RIBERA DE RÍO** |  |  |  |  |  |  |  |  |  |
|  | 15 | **REFUERZO DE TALUDES** |  |  |  |  |  |  |  |  |  |
|  | 17 | **ESTRUCTURA DE CRUCE** |  |  | 2024-12-31 | 2025-04-29 |  |  |  |  |  |
| C.70.17.30 |  | Sifón Integrador (Km 21+772) |  | 30d | 2024-12-31 | 2025-01-29 | C.70.10.01.01.70, C.70.10.01.01.80, C.70.01.01 | 0d |  | Recurso Lacramarca [101937 h]; Recurso Lacramarca - NLU [720.07 h] | 101,937.14 |
| C.70.17.10 |  | Captación (Km 21+079.91) |  | 30d | 2025-01-30 | 2025-02-28 | C.70.17.30, C.70.10.02.01.10, C.70.10.02.01.20, C.70.10.02.01.30, C.70.01.01 | 0d |  | Recurso Lacramarca [430636 h]; Recurso Lacramarca - NLU [4577.86 h] | 430,636.16 |
| C.70.17.40 |  | Captación (Km 23+946.16) |  | 30d | 2025-03-01 | 2025-03-30 | C.70.17.10, C.70.01.01, C.70.10.02.01.70, C.70.10.02.01.80 | 0d |  | Recurso Lacramarca [1069912 h]; Recurso Lacramarca - NLU [10488.7 h] | 1,069,912.44 |
| C.70.17.20 |  | Retorno (Km 21+547.54) |  | 30d | 2025-03-31 | 2025-04-29 | C.70.17.40, C.70.01.01 | 0d |  | Recurso Lacramarca [225290 h]; Recurso Lacramarca - NLU [1670.59 h] | 225,289.77 |
|  | 21 | **REGISTROS Y CÁMARAS** |  |  |  |  |  |  |  |  |  |
|  | 22 | **DRENAJE URBANO** |  |  |  |  |  |  |  |  |  |
|  | 80 | **FACILIDADES DE OBRA** |  |  |  |  |  |  |  |  |  |
|  | 02 | **DEMOLICIONES** |  |  |  |  |  |  |  |  |  |
|  | 04 | **OBRAS DE DESVÍO TEMPORAL** |  |  |  |  |  |  |  |  |  |
|  | 90 | **TRABAJO PRELIMINARES** |  |  |  |  |  |  |  |  |  |
|  | 02 | **COSTOS DEL CONTRATISTA PRINCIPAL** |  |  |  |  |  |  |  |  |  |
|  | 03 | **GASTOS GENERALES** |  |  |  |  |  |  |  |  |  |
|  | U | **USO** |  |  |  |  |  |  |  |  |  |
|  | 30 | **ENTRENAMIENTO** |  |  |  |  |  |  |  |  |  |
|  | 40 | **MANTENIMIENTO** |  |  |  |  |  |  |  |  |  |
|  | 01 | **MANTENIMIENTO PLANEADO** |  |  |  |  |  |  |  |  |  |
|  | T | **CIERRE** |  |  | 2024-12-31 | 2025-04-29 |  |  |  |  |  |
|  | 20 | **DESMOVILIZACIÓN** |  |  | 2024-12-31 | 2025-04-29 |  |  |  |  |  |
|  | 20 | **DESMOVILIZACIÓN** |  |  | 2024-12-31 | 2025-04-29 |  |  |  |  |  |
| T.20.20.01 |  | Programa de cierre de la obra | level of effort | 120d | 2024-12-31 | 2025-04-29 | C.70.10.02.02.70, C.70.10.02.02.80, C.70.10.01.01.70, C.70.10.01.01.80, C.70.10.01.02.01.70, C.70.10.01.02.01.80, C.70.10.01.02.02.70, C.70.10.01.02.02.80, C.70.10.01.02.03.70, C.70.10.01.02.03.80, C.70.10.02.01.70, C.70.10.02.01.80 | 0d |  | Recurso Lacramarca [1521649 h]; Recurso Lacramarca - NLU [5411.39 h] | 1,521,649.37 |

| WBS | Activity |
| --- | --- |
| 40 | **REPORTE FINAL** |
| 40 | **REPORTE FINAL** |
| 930 | **PUENTES** |
| P | **PROCURA** |
| 40 | **CONSULTOR ESPECIALIZADO** |
| 50 | **PROVEEDOR** |
| C | **CONSTRUCCIÓN** |
| 00 | **GENERAL** |
| 00 | **GENERAL** |
| 01 | **LIMPIEZA DE SITIO** |
| 10 | **SUBESTRUCTURA** |
| 01 | **FUNDACIONES ESTÁNDAR** |
| 02 | **CIMENTACIONES ESPECIALES** |
| 20 | **SUPERESTRUCTURA** |
| 01 | **MARCOS (CUBIERTAS)** |
| 03 | **TECHOS** |
| 04 | **ESCALERAS Y RAMPAS** |
| 05 | **MUROS EXTERIORES** |
| 09 | **PILARES DE PUENTE** |
| 10 | **ESTRIBOS DE PUENTE** |
| 11 | **CUBIERTAS DE PUENTE** |
| 12 | **PARAPETO DE PUENTE** |
| 25 | **INSTALACIONES ESPECIALES** |
| 01 | **APOYOS PARA PUENTES** |
| 30 | **ACABADOS** |
| 02 | **ACABADO PARA PISOS** |
| 60 | **TRABAJOS DE RENOVACIÓN** |
| 02 | **REPARACIÓN DE SERVICIOS EXISTENTES** |
| 70 | **OBRAS EXTERIORES** |
| 00 | **GENERAL** |
| 01 | **PREPARACIÓN DE SITIO** |
| 02 | **CAMINOS PROVISIONALES** |
| 03 | **PLANTACIÓN Y PAISAJISMO** |
| 05 | **MOBILIARIO Y EQUIPAMIENTO URBANO** |
| 10 | **CUERPOS DE TERRAPLÉN** |
| 11 | **SUPERFICIES DE TERRAPLÉN** |
| 12 | **MEJORAS EN LOS TERRAPLENES** |
| 13 | **CANALIZACIÓN** |
| 14 | **REFUERZO DE RIBERA DE RÍO** |
| 15 | **REFUERZO DE TALUDES** |
| 17 | **ESTRUCTURA DE CRUCE** |
| 21 | **REGISTROS Y CÁMARAS** |
| 22 | **DRENAJE URBANO** |
| 80 | **FACILIDADES DE OBRA** |
| 02 | **DEMOLICIONES** |
| 04 | **OBRAS DE DESVÍO TEMPORAL** |
| 90 | **TRABAJO PRELIMINARES** |
| 02 | **COSTOS DEL CONTRATISTA PRINCIPAL** |
| 03 | **GASTOS GENERALES** |
| U | **USO** |
| 30 | **ENTRENAMIENTO** |
| 40 | **MANTENIMIENTO** |
| 01 | **MANTENIMIENTO PLANEADO** |
| T | **CIERRE** |
| 20 | **DESMOVILIZACIÓN** |
| 20 | **DESMOVILIZACIÓN** |
| 40 | **REPORTE FINAL** |
| 40 | **REPORTE FINAL** |
| 890 | **ARQUITECTURA, URBANISMO Y PAISAJISMO** |
| P | **PROCURA** |
| 40 | **CONSULTOR ESPECIALIZADO** |
| 50 | **PROVEEDOR** |
| C | **CONSTRUCCIÓN** |
| 00 | **GENERAL** |
| 00 | **GENERAL** |
| 01 | **LIMPIEZA DE SITIO** |
| 10 | **SUBESTRUCTURA** |
| 01 | **FUNDACIONES ESTÁNDAR** |
| 02 | **CIMENTACIONES ESPECIALES** |
| 20 | **SUPERESTRUCTURA** |

| WBS | Activity |
| --- | --- |
| 01 | **MARCOS (CUBIERTAS)** |
| 03 | **TECHOS** |
| 04 | **ESCALERAS Y RAMPAS** |
| 05 | **MUROS EXTERIORES** |
| 09 | **PILARES DE PUENTE** |
| 10 | **ESTRIBOS DE PUENTE** |
| 11 | **CUBIERTAS DE PUENTE** |
| 12 | **PARAPETO DE PUENTE** |
| 25 | **INSTALACIONES ESPECIALES** |
| 01 | **APOYOS PARA PUENTES** |
| 30 | **ACABADOS** |
| 02 | **ACABADO PARA PISOS** |
| 60 | **TRABAJOS DE RENOVACIÓN** |
| 02 | **REPARACIÓN DE SERVICIOS EXISTENTES** |
| 70 | **OBRAS EXTERIORES** |
| 00 | **GENERAL** |
| 01 | **PREPARACIÓN DE SITIO** |
| 02 | **CAMINOS PROVISIONALES** |
| 03 | **PLANTACIÓN Y PAISAJISMO** |
| 05 | **MOBILIARIO Y EQUIPAMIENTO URBANO** |
| 10 | **CUERPOS DE TERRAPLÉN** |
| 11 | **SUPERFICIES DE TERRAPLÉN** |
| 12 | **MEJORAS EN LOS TERRAPLENES** |
| 13 | **CANALIZACIÓN** |
| 14 | **REFUERZO DE RIBERA DE RÍO** |
| 15 | **REFUERZO DE TALUDES** |
| 17 | **ESTRUCTURA DE CRUCE** |
| 21 | **REGISTROS Y CÁMARAS** |
| 22 | **DRENAJE URBANO** |
| 80 | **FACILIDADES DE OBRA** |
| 02 | **DEMOLICIONES** |
| 04 | **OBRAS DE DESVÍO TEMPORAL** |
| 90 | **TRABAJO PRELIMINARES** |
| 02 | **COSTOS DEL CONTRATISTA PRINCIPAL** |
| 03 | **GASTOS GENERALES** |
| U | **USO** |
| 30 | **ENTRENAMIENTO** |
| 40 | **MANTENIMIENTO** |
| 01 | **MANTENIMIENTO PLANEADO** |
| T | **CIERRE** |
| 20 | **DESMOVILIZACIÓN** |
| 20 | **DESMOVILIZACIÓN** |
| 40 | **REPORTE FINAL** |
| 40 | **REPORTE FINAL** |

## Activity codes

| Code | Value | Meaning |
| --- | --- | --- |
| Lacramarca | D | Descolmatación |
| Lacramarca | E | Excavación |
| Lacramarca | G | Geotextil |
| Lacramarca | N | Enrocado |
| Lacramarca | R | Relleno |
